# HMG_01

Schedule from MS Project, 2017-11-29 to 2018-08-06.

## Calendars

- Standardní: Mon-Fri 09:00-13:00, 14:00-18:00; Sat-Sun off.

## Schedule

| ID | Task | Duration | Start | Finish | Predecessors | Total slack | Text1 | Text2 |
| --- | --- | --- | --- | --- | --- | --- | --- | --- |
| 1 | Preconstruction | 5d | 2017-11-29 | 2017-12-05 |  | 0d |  |  |
| 2 | Level 1: Floor Slab / Foundations | 10d | 2017-12-06 | 2017-12-19 | 1 | 0d | Construct | 110 |
| 3 | Level 1: Columns | 5d | 2017-12-20 | 2017-12-26 | 2 | 0d | Construct | 120 |
| 4 | Level 1: Beams | 8d | 2017-12-27 | 2018-01-05 | 3 | 0d | Construct | 130 |
| 5 | Level 1: Joists | 10d | 2018-01-08 | 2018-01-19 | 4 | 0d | Construct | 140 |
| 6 | Level 1: Exterior Walls | 10d | 2018-01-22 | 2018-02-02 | 5 | 0d | Construct | 150 |
| 7 | Level 2: Floor Deck | 5d | 2018-02-05 | 2018-02-09 | 6 | 0d | Construct | 210 |
| 8 | Level 2: Columns | 5d | 2018-02-12 | 2018-02-16 | 7 | 0d | Construct | 220 |
| 9 | Level 2: Beams | 8d | 2018-02-19 | 2018-02-28 | 8 | 0d | Construct | 230 |
| 10 | Level 2: Joists | 10d | 2018-03-01 | 2018-03-14 | 9 | 0d | Construct | 240 |
| 11 | Level 2: Exterior Walls | 10d | 2018-03-15 | 2018-03-28 | 10 | 0d | Construct | 250 |
| 12 | Level 3: Floor Deck | 5d | 2018-03-29 | 2018-04-04 | 11 | 0d | Construct | 310 |
| 13 | Level 3: Columns | 5d | 2018-04-05 | 2018-04-11 | 12 | 0d | Construct | 320 |
| 14 | Level 3: Beams | 8d | 2018-04-12 | 2018-04-23 | 13 | 0d | Construct | 330 |
| 15 | Level 3: Joists | 10d | 2018-04-24 | 2018-05-07 | 14 | 0d | Construct | 340 |
| 16 | Level 3: Exterior Walls | 10d | 2018-05-08 | 2018-05-21 | 15 | 0d | Construct | 350 |
| 17 | Level 4: Roof | 5d | 2018-05-22 | 2018-05-28 | 16 | 0d | Construct | 410 |
| 18 | All: Stairs | 10d | 2018-05-29 | 2018-06-11 | 17 | 0d | Construct | 510 |
| 19 | All: Windows & Doors | 10d | 2018-06-12 | 2018-06-25 | 18 | 0d | Construct | 610 |
| 20 | All: Curtain Walls | 10d | 2018-06-26 | 2018-07-09 | 19 | 0d | Construct | 710 |
| 21 | All: Railings | 5d | 2018-07-10 | 2018-07-16 | 20 | 0d | Construct | 810 |
| 22 | All: Interior Walls | 15d | 2018-07-17 | 2018-08-06 | 21 | 0d | Construct | 910 |
